# Example of Resource Loading

Schedule from Primavera P6, 2014-03-24 to 2014-07-30, data date 2014-03-22, costs in USD.

## Calendars

- Corporate - Standard Full Time: Mon-Fri 08:00-16:00; Sat-Sun off.

## Resources

| Resource | Group | Rate |
| --- | --- | --- |
| Project Managers | labor | 50 |
| Process Engineering | labor |  |
| Mechanical Drafting | labor |  |
| Civil Engineering | labor |  |
| Electrical Engineering | labor |  |

## Schedule

| ID | WBS | Activity | Type | Duration | Start | Finish | Predecessors | Total float | Free float | Resources | Cost |
| --- | --- | --- | --- | --- | --- | --- | --- | --- | --- | --- | --- |
|  | 1 | **Resources** |  |  | 2014-03-24 | 2014-07-30 |  |  |  |  |  |
| A1000 |  | Project Management | level of effort | 93d | 2014-03-24 | 2014-07-30 | A1010 SS | 0d |  | Project Managers [800 h] | 40,000 |
| A1180 |  | Process Engineering | level of effort | 35d | 2014-03-24 | 2014-05-09 | A1010 SS | 58d | 0d | Process Engineering [280 h] |  |
| A1190 |  | Mechanical Drafting | level of effort | 58d | 2014-04-07 | 2014-06-25 | A1040 SS | 25d | 0d | Mechanical Drafting [500 h] |  |
| A1200 |  | Civil Engineering | level of effort | 30d | 2014-05-28 | 2014-07-08 | A1100 SS | 16d | 0d | Civil Engineering [250 h] |  |
| A1210 |  | Electrical Engineering | level of effort | 30d | 2014-06-19 | 2014-07-30 | A1120 SS | 0d |  | Electrical Engineering [250 h] |  |
|  | 2 | **Process Engineering** |  |  | 2014-03-24 | 2014-05-09 |  |  |  |  |  |
| A1010 |  | IFA |  | 20d | 2014-03-24 | 2014-04-18 |  | 0d |  | Process Engineering |  |
| A1020 |  | HAZOP |  | 5d | 2014-04-21 | 2014-04-25 | A1010 | 58d | 0d | Process Engineering |  |
| A1030 |  | IFC |  | 10d | 2014-04-28 | 2014-05-09 | A1020, A1180 FF | 58d |  | Process Engineering |  |
|  | 3 | **Mechanical Drafting** |  |  | 2014-04-07 | 2014-06-18 |  |  |  |  |  |
| A1040 |  | 30% Model Development |  | 20d | 2014-04-07 | 2014-05-02 | A1010 SS+10d | 0d |  | Mechanical Drafting |  |
| A1050 |  | 30% Model Review |  | 1d | 2014-05-05 | 2014-05-05 | A1040 | 0d |  | Mechanical Drafting |  |
| A1060 |  | 60% Model Development |  | 15d | 2014-05-06 | 2014-05-26 | A1050 | 0d |  | Mechanical Drafting |  |
| A1070 |  | 60% Model Review |  | 1d | 2014-05-27 | 2014-05-27 | A1060 | 0d |  | Mechanical Drafting |  |
| A1080 |  | 90% Model Development |  | 10d | 2014-05-28 | 2014-06-10 | A1070 | 0d |  | Mechanical Drafting |  |
| A1090 |  | 90% Model Review |  | 1d | 2014-06-11 | 2014-06-11 | A1080 | 0d |  | Mechanical Drafting |  |
| A1170 |  | Issue General Arangement Drawings |  | 5d | 2014-06-12 | 2014-06-18 | A1090 | 0d |  | Mechanical Drafting |  |
|  | 4 | **Civil Engineering** |  |  | 2014-05-28 | 2014-07-01 |  |  |  |  |  |
| A1100 |  | IFA |  | 20d | 2014-05-28 | 2014-06-24 | A1070 | 16d | 0d | Civil Engineering |  |
| A1110 |  | IFC |  | 5d | 2014-06-25 | 2014-07-01 | A1100 | 16d | 0d | Civil Engineering |  |
|  | 5 | **Electrical Engineering** |  |  | 2014-06-19 | 2014-07-23 |  |  |  |  |  |
| A1120 |  | IFA |  | 20d | 2014-06-19 | 2014-07-16 | A1170 | 0d |  | Electrical Engineering |  |
| A1130 |  | IFC |  | 5d | 2014-07-17 | 2014-07-23 | A1120 | 0d |  | Electrical Engineering |  |

| ID | WBS | Activity | Duration | Start | Finish | Predecessors | Total float | Resources |
| --- | --- | --- | --- | --- | --- | --- | --- | --- |
|  | 6 | **Construction Work Packages** |  | 2014-06-19 | 2014-07-30 |  |  |  |
| A1140 |  | Mechanical Package | 5d | 2014-06-19 | 2014-06-25 | A1170, A1190 FF | 25d | Mechanical Drafting |
| A1150 |  | Civil Package | 5d | 2014-07-02 | 2014-07-08 | A1110, A1200 FF | 16d | Civil Engineering |
| A1160 |  | Electrical Package | 5d | 2014-07-24 | 2014-07-30 | A1000 FF, A1210 FF, A1130 | 0d | Electrical Engineering |
